# Stage-1-Project-Plan

Schedule from MS Project, 2014-01-01 to 2015-06-19.

## Calendars

- Standard: Mon-Fri 08:00-12:00, 13:00-17:00; Sat-Sun off.

## Resources

| Resource |
| --- |
| Guo |
| Svetek |
| Klabbers |
| Cali |
| Iles |
| Gorski |
| Da Silva |
| Zabi |
| Anatoli |
| Marcelo |
| LLR-Tech-1 |
| LLR-Tech-2 |
| Yannick |
| Thierry |
| UW Student 1 |
| Thea |
| Firmware Enginner 1 |
| Firmware Engineer 2 |
| Rice PostDoc |
| FNAL PostDoc |
| GM Innocenti |
| M Guilbaud |
| Newbold |
| Dasgupta |
| BU |
| Tapper |
| Brooke |
| T. Durkin |
| A Rose |
| A Bundock |
| J Marrouche |
| J Baptist |
| K. Harder |
| Jeitler |
| S Harper |
| Luca Mastrolorenzo |
| Florian |
| Matias |

## Schedule

| ID | WBS | Task | Type | Duration | Start | Finish | Predecessors | Total slack | Free slack | Constraint | Resources | Work |
| --- | --- | --- | --- | --- | --- | --- | --- | --- | --- | --- | --- | --- |
| 1 | 1 | **Stage-1-Project-Plan** |  | 383d? | 2014-01-01 | 2015-06-19 |  | 0d |  |  |  | 26224.3h |
| 2 | 1.1 | Preliminary Patch Panel Installation at 904 |  | 1w | 2014-03-17 | 2014-03-21 |  | 167d | 0d | start no earlier than 2014-03-17 | T. Durkin | 40h |
| 3 | 1.2 | Preliminary System tests Layer-1/Layer-2 using MP7s at 904 |  | 2w | 2014-03-24 | 2014-04-04 | 2 | 19d | 0d | start no earlier than 2014-03-24 | Tapper; Iles; T. Durkin; Newbold; A Rose; Thea [50%] | 440h |
| 4 | 1.3 | MP7 Production + 2 MP7s |  | 1mo | 2014-04-01 | 2014-04-28 |  | 53d | 0d | start no earlier than 2014-04-01 | Iles [15%] | 24h |
| 5 | 1.4 | MP7 Testing firmware (MP7-suite) |  | 1mo | 2014-04-01 | 2014-04-28 |  | 88d | 0d | start no earlier than 2014-04-01 | A Bundock | 160h |
| 6 | 1.5 | MP7 Production + 4 MP7s and testing |  | 5w | 2014-04-29 | 2014-06-02 | 4, 5 | 53d | 0d |  | Iles [15%]; T. Durkin [20%] | 70h |
| 7 | 1.6 | MP7 Production + 10 MP7s and testing |  | 6w | 2014-06-03 | 2014-07-14 | 6 | 53d | 0d |  | Iles [15%]; A Bundock [20%] | 84h |
| 8 | 1.7 | Second MP7 production line for another 16 MP7s |  | 13w | 2014-05-01 | 2014-07-30 |  | 76d | 0d | start no earlier than 2014-05-01 | Iles [15%]; A Bundock [20%] | 182h |
| 9 | 1.8 | MP7 Production complete - 32 MP7 Cards available for use | milestone | 1d? | 2014-07-31 | 2014-07-31 | 8, 7 | 41d | 17d |  |  |  |
| 10 | 1.9 | P5 DAQ DAQ1--> DAQ2 --- DAQ GROUP |  | 31d? | 2014-04-14 | 2014-05-26 |  | 77d | 0d | start no earlier than 2014-04-14 |  |  |
| 11 | 1.10 | P5 DAQ2 Commissioning --- DAQ GROUP |  | 26d? | 2014-05-27 | 2014-07-01 | 10 | 77d | 0d | start no earlier than 2014-05-27 |  |  |
| 12 | 1.11 | MP7 DAQ Interface Firmware |  | 2mo | 2014-04-01 | 2014-05-26 |  | 160d | 5d | start no earlier than 2014-04-01 | Newbold [25%]; Dasgupta [50%] | 240h |
| 13 | 1.12 | Assemblying DAQ testsetup, FEDkit, MiniDAQ at 904 |  | 12w | 2014-04-01 | 2014-06-23 |  | 59d | 5d | start no earlier than 2014-04-01 | K. Harder | 480h |
| 14 | 1.13 | Final Version AMC13 Arrives at CERN | milestone | 1d? | 2014-06-02 | 2014-06-02 |  | 63d | 0d | start no earlier than 2014-06-02 |  |  |
| 15 | 1.14 | Integration MP7-DAQ interface with AMC13 |  | 4w | 2014-06-03 | 2014-06-30 | 14, 12 | 54d | 10d |  | Dasgupta; BU | 320h |
| 16 | 1.15 | Integration with DAQ2/XDAQ and testing |  | 4w | 2014-07-02 | 2014-07-29 | 15, 13, 11 | 77d | 0d |  | Thea; K. Harder | 320h |
| 17 | 1.16 | MP7 Data unpacker |  | 1mo | 2014-04-01 | 2014-04-28 |  | 143d | 66d | start no earlier than 2014-04-01 | Tapper; Brooke | 320h |
| 18 | 1.17 | MP7 - DAQ Interface and Data unpacking ready | milestone | 1d | 2014-07-30 | 2014-07-30 | 17, 16 | 77d | 3d |  |  |  |
| 19 | 1.18 | Firmware for MP7->Legacy GT-oGTI 3 GBps Intrface + Commissioning |  | 6w | 2014-04-07 | 2014-05-16 | 3 | 64d | 0d |  | Iles | 240h |
| 20 | 1.19 | DEMUX Firmware |  | 1mo | 2014-05-19 | 2014-06-13 | 19 | 64d | 10d |  | Iles [50%] | 80h |
| 21 | 1.20 | Installation and PC connection of the two Layer-2 uTCA MP7 Crates at P5 |  | 2w | 2014-06-16 | 2014-06-27 | 14 | 54d | 0d | start no earlier than 2014-06-16 | Iles [50%]; Thea [50%] | 80h |
| 22 | 1.21 | Integration with Legacy GT |  | 1w | 2014-06-30 | 2014-07-04 | 21, 20 | 54d | 0d |  | Iles; Jeitler | 80h |
| 23 | 1.22 | Interface of 2016 Trigger Layer-2 MP7 to Legacy GT oGTI Complete | milestone | 1d? | 2014-07-07 | 2014-07-07 | 22 | 54d | 10d |  |  |  |
| 24 | 1.23 | Installation of the 12 Layer-2 MP7s at the two crates at P5 |  | 1w | 2014-07-15 | 2014-07-21 | 7 | 94d | 0d |  | T. Durkin | 40h |
| 25 | 1.24 | 2016 Trigger Layer-2 12 MP7s installed in 2 crates at P5 | milestone | 1d? | 2014-07-22 | 2014-07-22 | 24 | 94d | 50d |  |  |  |
| 26 | 1.25 | First Version of the CMSSW Electron finder |  | 1mo | 2014-03-17 | 2014-04-11 |  | 105d | 0d | start no earlier than 2014-03-17 | J Baptist; S Harper; Tapper [20%] | 352h |
| 27 | 1.26 | First Version of the CMSSW Tau Algorithm |  | 8w | 2014-03-17 | 2014-05-09 |  | 129d | 102d | start no earlier than 2014-03-17 | Luca Mastrolorenzo; Florian | 640h |
| 28 | 1.27 | First version of the CMSSW Jet/MET/MHT/Ht/Et triggers WITH PU sub. |  | 2mo | 2014-03-17 | 2014-05-09 |  | 232d |  | start no earlier than 2014-03-17 | J Marrouche [50%]; Brooke | 480h |
| 29 | 1.28 | First Version Firmware of 2016 Trigger Electron Finder |  | 7w | 2014-03-17 | 2014-05-02 |  | 100d | 0d | start no earlier than 2014-03-17 | A Rose [50%]; Thierry | 420h |
| 30 | 1.29 | First Version Firmware of the 2016 Trigger Tau finder |  | 1mo | 2014-05-05 | 2014-05-30 | 29 | 130d | 30d |  | A Rose [50%]; Thierry | 240h |
| 31 | 1.30 | First Version of Jet/MET/MHT/Et/Ht Triggers with no PU |  | 4w | 2014-03-17 | 2014-04-11 |  | 105d | 0d | start no earlier than 2014-03-17 | A Rose [50%] | 80h |
| 32 | 1.31 | Pattern Testing of Jet/MET/MHT/Et/Ht Triggers woth no PU |  | 6w | 2014-04-14 | 2014-05-23 | 31, 26 | 62d | 0d |  | A Rose [50%] | 120h |
| 33 | 1.32 | First Version Firmware for the 2016 Jet/MET/MHT/Et/Ht Triggers + PU |  | 6w | 2014-05-26 | 2014-07-04 | 32 | 105d | 5d |  | A Rose | 240h |
| 34 | 1.33 | Pattern Tests for Commissioning Electron and tau Algorithms 904 |  | 1mo | 2014-05-05 | 2014-05-30 | 26, 29 | 100d | 0d |  | Thierry; Zabi [25%]; A Bundock | 360h |
| 35 | 1.34 | Pattern Tests for Commissionng Jet/MHT/MET/Et/Ht Triggers + PU 904 |  | 6w | 2014-06-02 | 2014-07-11 | 34 | 100d | 0d |  | A Bundock; J Marrouche [50%] | 360h |
| 36 | 1.35 | Development of Version 1 of Layer 2 Algorithm Firmware Complete | milestone | 1d? | 2014-07-14 | 2014-07-14 | 35, 33, 30 | 100d | 56d |  |  |  |
| 37 | 1.36 | CTP7 Prototype testing |  | 12w | 2014-04-01 | 2014-06-23 |  | 74d | 0d | start no earlier than 2014-04-01 | Gorski | 480h |
| 38 | 1.37 | CTP7 Pre-Production of 3-4 CTP7s |  | 1mo | 2014-06-24 | 2014-07-21 | 37 | 74d | 0d |  | Gorski [15%] | 24h |
| 39 | 1.38 | CTP7 Pre-Production testing |  | 1mo | 2014-07-22 | 2014-08-18 | 38 | 74d | 0d |  | Gorski | 160h |
| 40 | 1.39 | Final CTP7 production |  | 4w | 2014-10-01 | 2014-10-28 | 39 | 0d |  | start no earlier than 2014-10-01 |  |  |
| 41 | 1.40 | Final CTP7 Production testing |  | 4w | 2014-10-29 | 2014-11-25 | 40 | 0d |  |  |  |  |
| 42 | 1.41 | Shipping 3-4 Pre-production CTP7s to CERN |  | 1w | 2014-08-19 | 2014-08-25 | 39 | 144d | 0d |  |  |  |
| 43 | 1.42 | 3-4 Pre-Production CTP7s at CERN | milestone | 1d? | 2014-08-26 | 2014-08-26 | 42 | 144d | 0d |  |  |  |
| 44 | 1.43 | Shipping production CTP7s to CERN |  | 1w | 2014-11-26 | 2014-12-02 | 41 | 0d |  |  |  |  |
| 45 | 1.44 | CTP7 Production complete - All CTP7s at CERN | milestone | 1d? | 2014-12-03 | 2014-12-03 | 44 | 0d |  |  |  |  |
| 46 | 1.45 | CTP7 Service fiirmware+ Data pass-through - CTP7 at CERN 904 is required from 1.4.2014 |  | 4mo | 2014-04-01 | 2014-07-21 |  | 44d | 0d | start no earlier than 2014-04-01 | Marcelo | 640h |
| 47 | 1.46 | oSLB/uHTR-->CTP7-->MP7-->GT SLICE TEST TDR MILESTONE + DAQ at P5 |  | 2w | 2014-07-22 | 2014-08-04 | 23, 46 | 44d | 0d |  | Iles; Da Silva; A Rose; Gorski; Jeitler; Thea; Svetek; T. Durkin | 640h |
| 48 | 1.47 | Slice Test oSLB/oRM--CTP7-->MP7->GT Milestone Completed | milestone | 1d? | 2014-08-05 | 2014-08-05 | 47 | 44d | 0d |  |  |  |
| 49 | 1.48 | Firmware CTP7 Layer-1 TMT Version 1 |  | 2mo | 2014-08-06 | 2014-09-30 | 48 | 44d | 0d |  | Svetek | 320h |
| 50 | 1.49 | Firmware CTP7 Layer-1 TMT Version 2 |  | 2mo | 2014-10-01 | 2014-11-25 | 49 | 48d | 0d |  | Svetek [50%] | 160h |
| 51 | 1.50 | Layer-1 Firmware Development Complete | milestone | 1d? | 2014-11-26 | 2014-11-26 | 50 | 48d | 5d |  |  |  |
| 52 | 1.51 | Firmware for testing the Patch Panel connections using MP7 |  | 2mo | 2014-04-07 | 2014-05-30 | 3 | 206d | 62d |  | A Bundock | 320h |
| 53 | 1.52 | Layer-1 - Layer -2 Patch Panel manufacture |  | 12w | 2014-04-07 | 2014-06-27 | 3 | 146d | 0d |  | T. Durkin [15%] | 72h |
| 54 | 1.53 | Layer-1 - Layer -2 Patch-Panel precabling at RAL |  | 4w | 2014-06-30 | 2014-07-25 | 53 | 146d | 0d |  | T. Durkin | 160h |
| 55 | 1.54 | Layer-1 - Layer-2 Patch Panel shipping from RAL to P5 |  | 1w | 2014-07-28 | 2014-08-01 | 54 | 60d | 0d |  |  |  |
| 56 | 1.55 | Layer-1 - Layer-2 Patch Panel installation at CERN |  | 1w | 2014-08-04 | 2014-08-08 | 55 | 60d | 0d |  | T. Durkin | 40h |
| 57 | 1.56 | oSLB/uHTR Patch Panel Design |  | 1mo | 2014-04-01 | 2014-04-28 |  | 166d | 0d | start no earlier than 2014-04-01 |  |  |
| 58 | 1.57 | oSLB/uHTR Patch Panel manufacture and procurement |  | 12w | 2014-04-29 | 2014-07-21 | 57 | 166d | 0d |  |  |  |
| 59 | 1.58 | oSLB/oRM Patch Panel Transport to CERN |  | 1w | 2014-07-22 | 2014-07-28 | 58 | 166d | 6d |  |  |  |
| 60 | 1.59 | oSLB/uHTR to Layer -1 Patch Panel installation |  | 2w | 2014-08-06 | 2014-08-19 | 48, 59 | 160d |  |  |  |  |
| 61 | 1.60 | Layer-1 Crate Iinstallation (6 uTCA crates for CTP7) |  | 2w | 2014-08-11 | 2014-08-22 | 56, 48 | 146d | 2d |  |  |  |
| 62 | 1.61 | Commissioning of Layer-2 and Layer-1/Layer-2 Patch Panel and 1/3 Layer-1 |  | 2w | 2014-08-27 | 2014-09-09 | 52, 48, 9, 61, 43 | 144d | 0d |  | A Bundock; T. Durkin | 160h |
| 63 | 1.62 | Layer-2 + Patch Panel + 1/9 of Layer-1 Commissioned | milestone | 1d? | 2014-09-10 | 2014-09-10 | 62 | 144d |  |  |  |  |
| 64 | 1.63 | Integration of the 2016 Trigger at P5 with the DAQ and GT |  | 2w | 2014-09-01 | 2014-09-12 | 47, 18 | 55d | 0d | start no earlier than 2014-09-01 | Dasgupta; Tapper; Brooke; K. Harder; Newbold | 400h |
| 65 | 1.64 | Layer-2 + Patch Panel + 1/9 of Layer-1 Connected to GT and DAQ | milestone | 1d? | 2014-09-15 | 2014-09-15 | 64 | 55d | 11d |  |  |  |
| 66 | 1.65 | Commissioning of 2016 Trigger Part - 0 (V1 Firmware 12 MP7s+4 CTP7s) Patterns |  | 9w | 2014-10-01 | 2014-12-02 | 49, 36, 18, 65, 25, 63 | 44d | 1d |  | A Rose; A Bundock; Svetek [50%] | 900h |
| 67 | 1.66 | Commisioning - 12 MP7+ 36 CTP7 2016 trigger Patterns+ oSLB/uHTR data |  | 2mo | 2014-12-04 | 2015-01-28 | 66, 45, 50, 51, 25 | 0d |  |  | A Rose; A Bundock; Svetek | 960h |
| 68 | 1.67 | 2016 Trigger Ready for receiving and processing HCAL B/E uTCA data | milestone | 1d? | 2015-01-29 | 2015-01-29 | 67 | 0d |  |  |  |  |
| 69 | 1.68 | Commissioning HCAL B/E uHTR system with trigger |  | 5mo | 2015-01-30 | 2015-06-18 | 68 | 0d |  |  |  |  |
| 70 | 1.69 | Online Monitoring Software for the 2016 Trigger |  | 6mo | 2014-09-16 | 2015-03-02 | 65 | 78d |  |  |  |  |

Notes:
- 15: 11.3.2014 Dave Newbold / Hi, / There are several components, and some are not in our hands. I would say / the following is the task list, where the time estimates include test / and debug. They are basically sequential, i.e. one cannot be done with / the previous ones. / - MP7 firmware - 1 month [Dasgupta, Newbold] / - AMC13 interface - 1 month [BU, Dasgupta] / - Integration with DAQ2 / XDAQ and test - 1 month [Harder, Thea] / - Unpackers, integration with CMSSW - 1 month [Tapper, Brooke] / This sounds bad, but note that these tasks overlap 100% with the work / required for other Stage-2 boards, i.e. *every* component can be the / same for MP7, CTP7, MTF7 in principle. This would require some / agreement, however. / Note that the AMC13 interface and integration with DAQ are stalled right / now waiting on other people. / Also note that *all* these tasks are also required for Stage-1, or we / cannot read out either the MP7 or CTP7. / Dave
- 16: 11.3.2014 Dave Newbold / Hi, / There are several components, and some are not in our hands. I would say / the following is the task list, where the time estimates include test / and debug. They are basically sequential, i.e. one cannot be done with / the previous ones. / - MP7 firmware - 1 month [Dasgupta, Newbold] / - AMC13 interface - 1 month [BU, Dasgupta] / - Integration with DAQ2 / XDAQ and test - 1 month [Harder, Thea] / - Unpackers, integration with CMSSW - 1 month [Tapper, Brooke] / This sounds bad, but note that these tasks overlap 100% with the work / required for other Stage-2 boards, i.e. *every* component can be the / same for MP7, CTP7, MTF7 in principle. This would require some / agreement, however. / Note that the AMC13 interface and integration with DAQ are stalled right / now waiting on other people. / Also note that *all* these tasks are also required for Stage-1, or we / cannot read out either the MP7 or CTP7. / Dave
- 37: The duration comes from info from UW (Pams talk Trigger meeting in Feb 2014) plus one month to be safe
- 40: GAP DRIVEN BY US FUNDING PROFILE: / Dear Costas: / Main production starts on Oct. 1, 2014 / (This is funding-driven as is the case for the uHTRs). / Installation starts on Dec. 8, 2014 / These are the dates from the US CMS Schedule and designed / so that the Calorimeter Trigger is ready for connection to the HCAL / uHTRs when they are installed. / We expect to install preproduction CTP7 cards in P5 this summer. / If these dates cause a problem for a plan to have Stage 2 operating / on Jan 2016, please let me know and I will discuss / with US CMS Management. / Best regards, / Wesley 16.3.2014
- 42: Dear Costas: / We would expect to have 3-4 preproduction CTP7s available for these tests. / Regards, / Wesley 18.3.2014 / On Mar 17, 2014, at 5:36 PM, Costas Fountas <Costas.Fountas@cern.ch> wrote: / Dear Wesley / One more thing that it is important is the following: / We should try to make the July Slice Milestone by hook and crook. / This means that you have a number of pre-production CTP7s / to participate to the slice test. / I would guess 1/3 of the total must be enough. Is this possible ? / Regards / costas
- 45: The assumption here is that no surpirses and no disasters occur which require significant redesign....of this happens all bets are off.....
- 47: Dear Costas, / I think July 14 slice test is a good goal. We have the CTP7 / for it and people allocated to do the layer-1 firmware. It / looks feasible from my point of view. / Regards, / Sridhara 2.4.2014
- 53: Tim Durkin estimates 12 weeks for manufacture
- 54: Tim Durkin estimates 4 weeks for precabling at RAL
- 62: Thre are 12 MP7 in Layer 2 and each has as inputs 2 ribons of 36 fibers each. So we have in total 24 Ribons and 24x36=864 fibers coming in to Layer-2 at 10 GBps / There are 36 CTP7 each with 2 ribbons of 12 fibers. So we have 36x2 = 72 ribons. In other words there are 72x12 = 864 fibers coming out of Layer-1

| ID | WBS | Task | Type | Duration | Start | Finish | Predecessors | Total slack | Free slack | Constraint | Resources | Work |
| --- | --- | --- | --- | --- | --- | --- | --- | --- | --- | --- | --- | --- |
| 71 | 1.70 | 2016 Trigger final Emulators |  | 4mo | 2014-10-01 | 2015-01-20 | 26, 27, 28, 36 | 27d | 0d | start no earlier than 2014-10-01 |  |  |
| 72 | 1.71 | Final Firmware for the 2016 Trigger + Validation |  | 4mo | 2015-01-21 | 2015-05-12 | 36, 66, 71 | 27d |  | start no earlier than 2014-10-01 |  |  |
| 73 | 1.72 | 2016 Trigger Ready for Data Taking | milestone | 1d? | 2015-06-19 | 2015-06-19 | 69, 70, 72 | 0d |  |  |  |  |
| 74 | 1.73 | ORSc Firmware - V1 for the APRIL2014 RCT->ORSc->MP7 test |  | 83d | 2014-01-01 | 2014-04-25 |  | 73d | 0d | start no earlier than 2014-01-01 | Svetek [10%]; Matias [80%] | 597.6h |
| 75 | 1.74 | ORSc Testing software for the April-2014 RCT->ORSc->MP7 test |  | 83d | 2014-01-01 | 2014-04-25 |  | 73d | 0d | start no earlier than 2014-01-01 | Klabbers; Cali | 1328h |
| 76 | 1.75 | RCT-ORSc-MP7 -- Integration Tests at 904 - 10 GBps Links |  | 3w | 2014-04-28 | 2014-05-16 | 74, 75 | 73d | 0d |  | Svetek [50%]; Cali [50%]; Klabbers [50%]; Iles [50%] | 240h |
| 77 | 1.76 | ORSCs Integrated with RCT and MP7 and ready for production | milestone | 1d? | 2014-05-19 | 2014-05-19 | 76 | 73d | 0d |  |  |  |
| 78 | 1.77 | ORSc Firmware for Integration with Legacy GCT |  | 1mo | 2014-05-20 | 2014-06-16 | 77 | 79d | 0d |  | Iles [20%]; Marcelo | 192h |
| 79 | 1.78 | OSCs integration tests with Legacy GCT - 2GBps links |  | 1mo | 2014-06-17 | 2014-07-14 | 78 | 79d | 0d |  | Iles [20%]; Marcelo | 192h |
| 80 | 1.79 | ORSCs Integrated with Legacy GCT | milestone | 1d? | 2014-07-15 | 2014-07-15 | 79 | 79d | 0d |  |  |  |
| 81 | 1.80 | 1st Global Run April 7.4 - 11.4 |  | 5d? | 2014-04-07 | 2014-04-11 |  | 309d |  | start no earlier than 2014-04-07 |  |  |
| 82 | 1.81 | ORSc Production |  | 1mo | 2014-05-20 | 2014-06-16 | 77 | 73d | 0d |  | Gorski [50%] | 80h |
| 83 | 1.82 | ORSc Testing at Madison |  | 1mo | 2014-06-17 | 2014-07-14 | 82 | 73d | 0d |  | Gorski | 160h |
| 84 | 1.83 | Easter Week 18.4 - 21.4 |  | 2d? | 2014-04-18 | 2014-04-21 |  | 303d |  | start no earlier than 2014-04-18 |  |  |
| 85 | 1.84 | Power off at P5 |  | 16d? | 2014-04-29 | 2014-05-20 |  | 282d |  | start no earlier than 2014-04-29 |  |  |
| 86 | 1.85 | Commissioning Software testing interconnectivity at P5 |  | 1mo | 2014-04-28 | 2014-05-23 | 75 | 135d | 62d |  | GM Innocenti | 160h |
| 87 | 1.86 | Installation of uTCA Crate at P5 with MP7 |  | 2w | 2014-05-20 | 2014-06-02 | 77 | 109d | 36d |  | Iles | 80h |
| 88 | 1.87 | ORSCs Testing complete | milestone | 1d? | 2014-07-15 | 2014-07-15 | 83 | 73d | 0d |  |  |  |
| 89 | 1.88 | ORSc transport US-->CERN |  | 1w | 2014-07-16 | 2014-07-22 | 88 | 73d | 0d |  |  |  |
| 90 | 1.89 | ORSC Installation at P5 including all fibers to GCT+MP7 + Patch Panel |  | 1mo | 2014-07-23 | 2014-08-19 | 89, 87 | 73d | 0d |  | Cali; Klabbers | 320h |
| 91 | 1.90 | Comissioning ECAL/HCAL/ORSC/MP7 system interconnectivity at P5 with ORSC gen. Patterns |  | 20d | 2014-08-20 | 2014-09-16 | 90, 86, 80 | 73d | 0d |  | Cali | 160h |
| 92 | 1.91 | ORSCs Installation and testing with MP7 at P5 Complete | milestone | 1d? | 2014-09-17 | 2014-09-17 | 91 | 73d | 0d |  |  |  |
| 93 | 1.92 | ORSc firmware for running Stage-1 |  | 2mo | 2014-05-20 | 2014-07-14 | 77 | 80d | 1d |  | Guo | 320h |
| 94 | 1.93 | ORSC Firmware for running the Legacy trigger |  | 2mo | 2014-07-16 | 2014-09-09 | 93, 80 | 79d | 6d |  | Marcelo | 320h |
| 95 | 1.94 | 2nd Global Run 3.7 - 10.7.2014 |  | 6d? | 2014-07-03 | 2014-07-10 |  | 245d |  | start no earlier than 2014-07-03 |  |  |
| 96 | 1.95 | Comm the Legacy Running via ORSC 2GBps - Move 108 ECL - No Trigger |  | 1mo | 2014-09-18 | 2014-10-15 | 94, 92 | 73d | 0d |  | Iles [25%]; Thea; Marcelo | 360h |
| 97 | 1.96 | Legacy System Can Trigger with ORSc input | milestone | 1d? | 2014-10-16 | 2014-10-16 | 96 | 73d | 0d |  |  |  |
| 98 | 1.97 | Comissioning of the Stage-1 running firmware |  | 1mo | 2014-10-17 | 2014-11-13 | 92, 97 | 73d | 0d |  | Guo; Cali; Klabbers | 400h |
| 99 | 1.98 | Stage-1 Comm. In Parallel with Legacy | milestone | 1d? | 2014-11-14 | 2014-11-14 | 98 | 73d | 0d |  |  |  |
| 100 | 1.99 | ORSc firmware for testing+Validation+Monitoring the Legacy system+Comm |  | 2mo | 2014-11-17 | 2015-01-09 | 99 | 114d |  |  | Marcelo | 320h |
| 101 | 1.100 | ORSc Software for testing+Validation+Monitoring the Legacy System+Comm |  | 2mo | 2014-11-17 | 2015-01-09 | 99 | 113d | 0d |  | Thea [50%]; M Guilbaud | 480h |
| 102 | 1.101 | Legacy System Fully Integrated with ORSc | milestone | 1d? | 2015-01-12 | 2015-01-12 | 101, 94 | 113d |  |  |  |  |
| 103 | 1.102 | Electron and Tau Algorithm Firmware development for MP7 |  | 6mo | 2014-04-01 | 2014-09-15 |  | 77d | 2d | start no earlier than 2014-04-01 | Firmware Enginner 1 | 960h |
| 104 | 1.103 | Electron and Tau Algorithm Pre comissioning at 904 |  | 2mo | 2014-09-18 | 2014-11-12 | 103, 92 | 75d | 0d |  | Firmware Enginner 1 | 320h |
| 105 | 1.104 | Electron and Tau Algorithm Commisioning at P5 |  | 1mo | 2014-11-13 | 2014-12-10 | 104 | 75d | 0d |  |  |  |
| 106 | 1.105 | Electron and Tau Trigger Validation vs Emulator |  | 3mo | 2014-12-11 | 2015-03-04 | 105 | 75d | 2d |  | Firmware Enginner 1; Cali | 960h |
| 107 | 1.106 | Monitoring Software for Stage -1 Electron and Tau Triggers |  | 4mo | 2014-11-17 | 2015-03-06 | 99 | 73d | 0d |  | GM Innocenti | 640h |
| 108 | 1.107 | Electron/Tau Triggers Ready and Validated | milestone | 1d? | 2015-03-09 | 2015-03-09 | 107, 106 | 73d |  |  |  |  |
| 109 | 1.108 | Jet+MET+MHT Algorithm Firmware Development |  | 6mo | 2014-04-01 | 2014-09-15 |  | 57d | 0d | start no earlier than 2014-04-01 | Firmware Engineer 2 | 960h |
| 110 | 1.109 | JET+MET+MHT Algorithm precommissining |  | 3mo | 2014-09-16 | 2014-12-08 | 109 | 57d | 0d |  | Firmware Engineer 2 | 480h |
| 111 | 1.110 | JET+MET+MHT Firmware Commissioning at P5 |  | 1mo | 2014-12-09 | 2015-01-05 | 99, 110 | 57d | 0d |  | Firmware Engineer 2 | 160h |
| 112 | 1.111 | JET+MET+MHT Trigger Validation vs Emulator |  | 3mo | 2015-01-06 | 2015-03-30 | 111 | 57d | 0d |  | Firmware Engineer 2; M Guilbaud | 960h |
| 113 | 1.112 | Monitoring Software for Stage -1 JET/MET/MHT (Hardonic Triggers) |  | 4mo | 2014-11-17 | 2015-03-06 | 99 | 73d | 16d |  |  |  |
| 114 | 1.113 | STAGE-1 MET/MHT/JETS AND ALL OTHER TRIGGERS DONE | milestone | 1d? | 2015-03-31 | 2015-03-31 | 112, 113 | 57d |  |  |  |  |
| 115 | 1.114 | oSLB - 650 - JTAG testing |  | 1mo | 2014-01-06 | 2014-01-31 |  | 282d | 0d | start no earlier than 2014-01-06 | Anatoli | 160h |
| 116 | 1.115 | oLSB - 650 - Programming - functionality testing - Links |  | 1mo | 2014-02-03 | 2014-02-28 | 115 | 282d | 0d |  | Marcelo; Da Silva [25%] | 200h |
| 117 | 1.116 | oLSB testing finished | milestone | 1d? | 2014-03-03 | 2014-03-03 | 116 | 338d |  |  |  |  |
| 118 | 1.117 | oRM - 650 - JTAG testing and Link testing |  | 1mo | 2014-02-12 | 2014-03-11 |  | 255d | 0d | start no earlier than 2014-02-12 | Anatoli | 160h |
| 119 | 1.118 | oRM - 650 - functionality testing - Links |  | 1mo | 2014-03-12 | 2014-04-08 | 118 | 255d | 0d |  | Marcelo [50%]; Klabbers [75%]; Anatoli [75%] | 320h |
| 120 | 1.119 | oRM Testing Finished | milestone | 1d? | 2014-04-09 | 2014-04-09 | 119 | 311d |  |  |  |  |
| 121 | 1.120 | oSLB TCC oRM/CTP7 + uHTR/CTP7 oRM Integration tests at 904 24.2 - 21.3 |  | 1mo | 2014-02-24 | 2014-03-21 |  | 257d | 0d | start no earlier than 2014-02-24 | Yannick; Da Silva [25%]; Marcelo [50%] | 226.67h |
| 122 | 1.121 | Last TCC/oSLB/oRM/RC/HTR-HCAL integration test at P5 24.3 - 4.4 |  | 2w | 2014-03-24 | 2014-04-04 | 121 | 257d | 2d |  | Klabbers [75%]; Da Silva [75%]; Yannick; Zabi | 280h |
| 123 | 1.122 | oLSB/oRM system ready for Installation - Final Go ahead | milestone | 1d? | 2014-04-09 | 2014-04-09 | 122, 119, 116 | 255d | 2d |  |  |  |
| 124 | 1.123 | 1ST GLOBAL RUN 7.4 - 11.4 - Legacy Trigger + 1 oSLB crate |  | 1w | 2014-04-07 | 2014-04-11 |  | 253d | 0d | start no earlier than 2014-04-07 |  |  |
| 125 | 1.124 | Removing ECAL Trigger Cables - Fiber Installation 1st week |  | 1w | 2014-04-14 | 2014-04-18 | 124, 123 | 253d | 1d |  | Zabi; LLR-Tech-1; LLR-Tech-2 | 120h |
| 126 | 1.125 | Easter Vacation Cern Closed 18.4 - 21.4 |  | 2d? | 2014-04-18 | 2014-04-21 |  | 252d | 0d | start no earlier than 2014-04-18 |  |  |
| 127 | 1.126 | Power off at P5 29.4 - 20.5 |  | 16d? | 2014-04-29 | 2014-05-20 |  | 282d |  | start no earlier than 2014-04-29 |  |  |
| 128 | 1.127 | Removing ECAL Trigger Cables - Fiber Installation 2d week |  | 1w | 2014-04-22 | 2014-04-28 | 124, 123, 126, 125 | 252d | 0d |  | Zabi; LLR-Tech-1; LLR-Tech-2 | 120h |
| 129 | 1.128 | Fiber Installation etc that require no rack power |  | 3w | 2014-04-29 | 2014-05-19 | 128 | 252d | 0d |  | LLR-Tech-1; Zabi; LLR-Tech-2 | 360h |
| 130 | 1.129 | oSLB - oRM installation and Commissioning Crate-by-Crate |  | 30d | 2014-05-20 | 2014-06-30 | 129 | 252d | 0d |  | Da Silva; Klabbers; Thierry; Zabi; Yannick | 1200h |
| 131 | 1.130 | oSLB-oRM Interface Ready for the Second CMS Global Run | milestone | 1d? | 2014-07-01 | 2014-07-01 | 130 | 252d |  |  |  |  |
| 132 | 1.131 | 2ND GLOBAL RUN 3.7 - 10.7 2014 - With Legacy RCT/GCT + oRM/oSLB |  | 6d? | 2014-07-03 | 2014-07-10 |  | 245d |  | start no earlier than 2014-07-03 |  |  |

Notes:
- 76: 2 weeks may not be enough considering that that needed 1 week just to agree on the protocol and yet not have an agreement.....
- 91: At this point we disconnet the 108 cables from the lagacy and connect the to ORSCs. / The ORSCs feed both the Legacy GCT as well as the MP7/Stage-1 crate
- 115: ·576 oSLBs (324 EB + 252 EE) with two output links; one for legacy one for upgrade
- 116: Hi Costas / You are assuming that it took a week to program 60…this is wrong… / We have stopped programming after the Slot#1 issue,… / we need 45min to program 18 oSLB and validate/check the configuration and 10 min link tests … so to program and test 620 we need one week! / Regards / JC / According to this we need about 650/18 = 36 hours which is a week. I will put down a month to be safe
- 119: ·565 (540 +25 HF) oRMs to receive the data on the RCT side
